# Project_case2_brigitte

Schedule from MS Project, 2003-09-01 to 2004-03-01.
BBWebmedia

## Calendars

- Standard: Mon-Fri 08:00-12:00, 13:00-17:00; Sat-Sun off.

## Resources

| Resource |
| --- |
| Project Manager |
| Instructional Designer |
| Content Expert |
| Instructional Designer; Graphic Artist |
| Instructional Designer; Developer |
| Developer |
| Instructinal Designer |
| Graphic Artist |
| Graphic Artist; Project Manager |
| Project Manager; Instructional Designer |
| Instructional Designer; Content Expert |
| Video/audio person |
| Developer 1 |
| Content Expert 1; Content Expert 2 |
| Content Expert 1; Content Expert 2; Instructional Designer |
| Developer 1; Developer 2; Developer 3; |
| Content writer/Copy editor |
| Content writer/Copy editor; Content Expert 1 |
| Instructional Designer; Developer 2 |
| Developer 2 |

## Schedule

| ID | WBS | Task | Duration | Start | Finish | Predecessors | Total slack | Free slack | Resources | Work |
| --- | --- | --- | --- | --- | --- | --- | --- | --- | --- | --- |
| 1 | 1000 | **Meet with Stakeholders** | 4d | 2003-09-01 | 2003-09-04 |  | 0d |  |  | 32h |
| 2 | 1100 | Discuss resources, constraints, and expectations | 1d | 2003-09-01 | 2003-09-01 |  | 0d |  | Project Manager | 8h |
| 3 | 1200 | Define Boundaries of project | 1d | 2003-09-02 | 2003-09-02 | 2 | 0d |  | Project Manager | 8h |
| 4 | 1300 | Discuss other important issues | 1d | 2003-09-03 | 2003-09-03 | 3 | 0d |  | Project Manager | 8h |
| 5 | 1400 | Agree on project boundaries and other issues | 1d | 2003-09-04 | 2003-09-04 | 4 | 0d |  | Project Manager | 8h |
| 7 | 2000 | **Design interface** | 16d | 2003-09-05 | 2003-09-26 | 1 | 149d | 0d |  | 144h |
| 8 | 2100 | **Design interface** | 5d | 2003-09-05 | 2003-09-11 | 1 | 149d | 0d |  | 40h |
| 9 | 2110 | Design a graphic to represent a timeline | 3d | 2003-09-05 | 2003-09-09 | 1 | 106d | 0d | Instructional Designer; Graphic Artist | 24h |
| 10 | 2120 | Plan and Design navigation and structural organization of ‘timeline’ feature using usability principles | 2d | 2003-09-10 | 2003-09-11 | 9 | 106d | 0d | Instructional Designer; Developer | 16h |
| 12 | 2200 | **Develop prototype** | 3d | 2003-09-12 | 2003-09-16 | 8 | 149d | 0d |  | 40h |
| 13 | 2210 | Create graphic | 2d | 2003-09-12 | 2003-09-15 | 9 | 107d |  | Graphic Artist | 16h |
| 14 | 2220 | Develop navigation and structural organization of timeline feature | 3d | 2003-09-12 | 2003-09-16 | 10 | 106d |  | Developer 1 | 24h |
| 16 | 2300 | **Test prototype** | 3d | 2003-09-17 | 2003-09-19 | 12 | 149d | 0d |  | 24h |
| 17 | 2310 | Have interface tested by user group | 2d | 2003-09-17 | 2003-09-18 | 8 | 106d | 0d | Instructional Designer | 16h |
| 18 | 2320 | Evaluate Results | 1d | 2003-09-19 | 2003-09-19 | 17 | 106d |  | Project Manager; Instructional Designer | 8h |
| 20 | 2400 | **Resume and Complete interface** | 5d | 2003-09-22 | 2003-09-26 | 16 | 149d |  |  | 40h |
| 21 | 2410 | Complete graphical Interface | 5d | 2003-09-22 | 2003-09-26 | 16 | 106d |  | Developer 1 | 40h |
| 23 | 3000 | **Develop Tutorial** | 125d | 2003-09-05 | 2004-02-26 | 1 | 0d |  |  | 2184h |
| 25 | 3100 | **Select content** | 30d | 2003-09-05 | 2003-10-16 |  | 0d |  |  | 480h |
| 26 | 3110 | Select text and photograph | 30d | 2003-09-05 | 2003-10-16 |  | 0d |  | Content Expert 1; Content Expert 2 | 240h |
| 27 | 3120 | Figure which other media need to be developed | 15d | 2003-09-05 | 2003-09-25 |  | 0d |  | Content Expert 1; Content Expert 2; Instructional Designer | 120h |
| 28 | 3130 | Write new content material as needed | 15d | 2003-09-26 | 2003-10-16 | 27 | 0d |  | Content writer/Copy editor; Content Expert 1 | 120h |
| 30 | 3200 | **Create other media needed** | 50d | 2003-09-26 | 2003-12-04 |  | 65d |  |  | 944h |
| 31 | 3210 | Create animation | 50d | 2003-09-26 | 2003-12-04 | 27 | 65d |  | Graphic Artist | 400h |
| 32 | 3220 | Create videos | 38d | 2003-09-26 | 2003-11-18 | 27 | 77d |  | Video/audio person | 304h |
| 33 | 3230 | Create audio | 30d | 2003-09-26 | 2003-11-06 | 27 | 85d |  | Video/audio person | 240h |

| ID | WBS | Task | Duration | Start | Finish | Predecessors | Total slack | Free slack | Resources | Work |
| --- | --- | --- | --- | --- | --- | --- | --- | --- | --- | --- |
| 35 | 3300 | **Design message design** | 15d | 2003-10-17 | 2003-11-06 | 25 | 0d |  |  | 120h |
| 36 | 3310 | Structure message design | 5d | 2003-10-17 | 2003-10-23 | 7 | 0d |  | Instructional Designer | 40h |
| 37 | 3320 | Create flowchart | 10d | 2003-10-24 | 2003-11-06 | 36 | 0d |  | Instructional Designer | 80h |
| 39 | 3400 | **Design templates** | 15d | 2003-11-07 | 2003-11-27 | 35 | 0d |  |  | 120h |
| 40 | 3410 | Design templates | 5d | 2003-11-07 | 2003-11-13 | 35 | 0d |  | Instructional Designer; Developer 2 | 40h |
| 41 | 3320 | Prototype templates | 10d | 2003-11-14 | 2003-11-27 | 40 | 0d |  | Developer 2 | 80h |
| 43 | 3400 | **Put content into template** | 65d | 2003-11-28 | 2004-02-26 | 39 | 0d |  |  | 520h |
| 44 | 3410 | Enter content in templates | 40d | 2003-11-28 | 2004-01-22 | 39 | 0d |  | Developer 1; Developer 2; Developer 3; | 320h |
| 45 | 3420 | Ensure quality assurance | 25d | 2004-01-23 | 2004-02-26 | 44 | 0d |  | Content writer/Copy editor | 200h |
| 47 | 4000 | **Create CD** | 131d | 2003-09-01 | 2004-03-01 |  | 0d |  |  | 72h |
| 49 | 4100 | **Design a cover** | 7d | 2003-09-01 | 2003-09-09 |  | 149d |  |  | 56h |
| 50 | 4110 | Design a cover | 1d | 2003-09-01 | 2003-09-01 |  | 119d | 0d | Graphic Artist | 8h |
| 51 | 4120 | Prototype cover design | 2d | 2003-09-02 | 2003-09-03 | 50 | 119d | 0d | Graphic Artist | 16h |
| 52 | 4130 | Show cover for approval | 1d | 2003-09-04 | 2003-09-04 | 51 | 119d | 0d | Project Manager | 8h |
| 53 | 4140 | Review cover | 1d | 2003-09-05 | 2003-09-05 | 52 | 119d | 0d | Graphic Artist; Project Manager | 8h |
| 54 | 4150 | Finalize cover | 1d | 2003-09-08 | 2003-09-08 | 53 | 119d | 0d | Graphic Artist | 8h |
| 55 | 4160 | Print cover | 1d | 2003-09-09 | 2003-09-09 | 54 | 119d |  | Graphic Artist | 8h |
| 57 | 4200 | **Create CD** | 2d | 2004-02-27 | 2004-03-01 | 23 | 0d |  |  | 16h |
| 58 | 4210 | Burn CD | 1d | 2004-02-27 | 2004-02-27 | 23 | 0d |  | Developer | 8h |
| 59 | 4220 | Test CD | 1d | 2004-03-01 | 2004-03-01 | 58 | 0d |  | Developer | 8h |
