# Gantt_final_project_9_v1_fixe _copy editor

Schedule from MS Project, 2003-09-01 to 2004-02-18, costs in $.
BBWebmedia

## Calendars

- Standard: Mon-Fri 08:00-12:00, 13:00-17:00; Sat-Sun off.

## Resources

| Resource | Rate |
| --- | --- |
| Instructor 1 |  |
| Instructor 2 | 27 |
| Instructor 3 | 27 |
| Instructional Designer | 27 |
| Developer 1 | 18 |
| Multimedia person | 18 |
| Copy editor | 20 |
| Sopport person | 15 |
| Project Manager | 35 |
| dummy |  |

## Schedule

| ID | WBS | Task | Duration | Start | Finish | Predecessors | Total slack | Free slack | Constraint | Resources | Work | Cost |
| --- | --- | --- | --- | --- | --- | --- | --- | --- | --- | --- | --- | --- |
| 1 | 1000 | **Project scope** | 2d | 2003-09-01 | 2003-09-02 |  | 42.2d |  |  |  | 80h | 2,288 |
| 2 | 1100 | Meet and discuss | 2d | 2003-09-01 | 2003-09-02 |  | 47.5d | 0d |  | Instructor 1; Instructor 2; Instructor 3; Instructional Designer; Project Manager | 80h | 2,288 |
| 5 | 2000 | **Content Revision Course #1** | 15d | 2003-09-03 | 2003-09-23 | 2 | 15d |  |  |  | 144h | 3,952 |
| 6 | 2100 | Create flowchart of current material | 3d | 2003-09-03 | 2003-09-05 | 2 | 47.5d | 0d |  | Instructional Designer | 24h | 648 |
| 7 | 2200 | Meet and discuss | 1d | 2003-09-08 | 2003-09-08 | 6 | 47.5d | 0d |  | Instructional Designer; Instructor 1; Project Manager | 24h | 712 |
| 8 | 2300 | Revise content | 10d | 2003-09-09 | 2003-09-22 | 7 | 3d | 0d |  | Instructor 1 | 80h | 2,160 |
| 9 | 2400 | Meet and discuss | 1d | 2003-09-23 | 2003-09-23 | 8 | 47d | 0d |  | Instructor 1; Instructional Designer | 16h | 432 |
| 10 | 3000 | **Development course #1** | 82d? | 2003-09-23 | 2004-01-14 | 2 | 25d |  |  |  | 560h | 10,768 |
| 11 | 3100 | Develop templates | 1d? | 2003-09-24 | 2003-09-24 | 2, 9 | 47d | 0d |  | Instructional Designer | 8h | 216 |
| 12 | 3200 | Enter text content into templates | 9d | 2003-09-25 | 2003-10-07 | 11, 9 | 3d | 0d |  | Sopport person | 72h | 1,080 |
| 13 | 3300 | **Develop other media** | 47d | 2003-09-23 | 2003-11-26 |  | 15d | 9d |  |  | 248h | 4,776 |
| 14 | 3310 | Develop graphics | 5d | 2003-09-23 | 2003-09-29 | 8 | 6.5d | 0d |  | Multimedia person | 40h | 720 |
| 15 | 3320 | Enter graphics into templates | 2d | 2003-11-03 | 2003-11-04 | 14, 64 | 3d | 0d |  | Sopport person | 16h | 240 |
| 16 | 3330 | Develop audio lectures | 5d | 2003-09-24 | 2003-09-30 | 9, 8 | 48d | 0d |  | Instructor 1 | 40h | 1,080 |
| 17 | 3340 | Develop audio lectures | 5d | 2003-10-01 | 2003-10-07 | 16 | 48d | 0d |  | Developer 1 | 40h | 720 |
| 18 | 3350 | Enter audio lectures into templates | 2d | 2003-10-22 | 2003-10-23 | 17, 69 | 38.2d | 0d |  | Developer 1 | 16h | 288 |
| 19 | 3360 | Develop animations | 10d | 2003-10-14 | 2003-10-27 | 8, 66 | 15d | 0d | start no earlier than 2003-08-13 | Multimedia person | 80h | 1,440 |
| 20 | 3370 | Enter animations into templates | 2d | 2003-11-25 | 2003-11-26 | 19, 71 | 15d | 0d |  | Multimedia person | 16h | 288 |
| 21 | 3400 | **Get course ready in WebCT** | 69d | 2003-10-10 | 2004-01-14 |  | 25d |  |  |  | 232h | 4,696 |
| 22 | 3910 | Set up course | 2d | 2003-10-10 | 2003-10-13 | 12 | 23d |  | start no earlier than 2003-10-10 | Instructional Designer | 16h | 432 |
| 23 | 3920 | Upload content material | 5d | 2003-12-10 | 2003-12-16 | 22, 12, 13, 65 | 10d | 0d | start no earlier than 2003-12-10 | Developer 1 | 40h | 720 |
| 24 | 3930 | Get quizzes ready | 5d | 2003-12-17 | 2003-12-23 | 23, 65 | 10d | 0d |  | Developer 1 | 40h | 720 |
| 25 | 3940 | Get discussions ready | 1d | 2003-12-24 | 2003-12-24 | 24 | 20d | 0d |  | Instructional Designer | 8h | 216 |
| 26 | 3950 | Get rest of course ready | 1d | 2003-12-25 | 2003-12-25 | 25 | 20d | 0d |  | Instructional Designer | 8h | 216 |
| 27 | 3960 | Revise course | 1d | 2003-12-26 | 2003-12-26 | 26 | 20d | 0d |  | Instructional Designer; Instructor 1 | 16h | 432 |
| 28 | 3960 | Revise course | 10d | 2003-12-29 | 2004-01-09 | 27 | 5d | 0d |  | Copy editor | 80h | 1,600 |
| 29 | 3970 | Upload revision | 3d | 2004-01-12 | 2004-01-14 | 28 | 25d |  |  | Sopport person | 24h | 360 |

| ID | WBS | Task | Duration | Start | Finish | Predecessors | Total slack | Free slack | Constraint | Resources | Work | Cost |
| --- | --- | --- | --- | --- | --- | --- | --- | --- | --- | --- | --- | --- |
| 31 | 2000 | **Content Revision Course #2** | 14.5d | 2003-09-10 | 2003-09-30 | 2 | 7d |  |  |  | 136h | 3,736 |
| 32 | 2100 | Create flowchart of current material | 3d | 2003-09-10 | 2003-09-12 | 2 | 42.5d | 0d | start no earlier than 2003-09-10 | Instructional Designer | 24h | 648 |
| 33 | 2200 | Meet and discuss | 1d | 2003-09-15 | 2003-09-15 | 32 | 42.5d | 0d |  | Instructional Designer; Project Manager; Instructor 2 | 24h | 712 |
| 34 | 2300 | Revise content | 10d | 2003-09-16 | 2003-09-29 | 33 | 42.5d | 0d |  | Instructor 2 | 80h | 2,160 |
| 35 | 2400 | Meet and discuss | 0.5d | 2003-09-30 | 2003-09-30 | 34 | 42.5d | 0d |  | Instructional Designer; Instructor 2 | 8h | 216 |
| 36 | 3000 | **Development Course 2** | 92d? | 2003-09-30 | 2004-02-04 | 2 | 10d |  |  |  | 560h | 10,768 |
| 37 | 3100 | Develop templates | 1d? | 2003-09-30 | 2003-10-01 | 35 | 42.5d | 0d |  | Instructional Designer | 8h | 216 |
| 38 | 3200 | Enter text content into templates | 9d | 2003-10-08 | 2003-10-20 | 35, 37, 12 | 3d | 0d |  | Sopport person | 72h | 1,080 |
| 39 | 3300 | **Develop other media** | 44d | 2003-09-30 | 2003-11-28 |  | 15d | 0d |  |  | 248h | 4,776 |
| 40 | 3310 | Develop graphics | 5d | 2003-09-30 | 2003-10-06 | 34 | 49d | 0d |  | Multimedia person | 40h | 720 |
| 41 | 3320 | Enter graphics into templates | 2d | 2003-11-05 | 2003-11-06 | 40, 15 | 3d | 0d |  | Sopport person | 16h | 240 |
| 42 | 3330 | Develop audio lectures | 5d | 2003-09-30 | 2003-10-07 | 35, 34 | 43.5d | 0d |  | Instructor 2 | 40h | 1,080 |
| 43 | 3340 | Develop audio lectures | 5d | 2003-10-08 | 2003-10-14 | 42, 17 | 42.2d | 0d |  | Developer 1 | 40h | 720 |
| 44 | 3350 | Enter audio lectures into templates | 2d | 2003-10-24 | 2003-10-27 | 43, 18 | 38.2d | 0d |  | Developer 1 | 16h | 288 |
| 45 | 3360 | Develop animations | 10d | 2003-10-28 | 2003-11-10 | 34, 19 | 15d | 0d |  | Multimedia person | 80h | 1,440 |
| 46 | 3370 | Enter animations into templates | 2d | 2003-11-27 | 2003-11-28 | 45, 20 | 15d | 0d |  | Multimedia person | 16h | 288 |
| 47 | 3400 | **Get course ready in WebCT** | 77d | 2003-10-21 | 2004-02-04 |  | 10d |  |  |  | 232h | 4,696 |
| 48 | 3910 | Set up course | 2d | 2003-10-21 | 2003-10-22 | 38 | 53d | 11d | start no earlier than 2003-10-13 | Instructional Designer | 16h | 432 |
| 49 | 3920 | Upload content material | 5d | 2003-12-01 | 2003-12-05 | 38, 39, 48 | 7d |  | start no earlier than 2003-11-07 | Developer 1 | 40h | 720 |
| 50 | 3930 | Get quizzes ready | 5d | 2004-01-07 | 2004-01-13 | 49, 24 | 0d |  | start no earlier than 2004-01-07 | Developer 1 | 40h | 720 |
| 51 | 3940 | Get discussions ready | 1d | 2004-01-14 | 2004-01-14 | 50 | 0d |  |  | Instructional Designer | 8h | 216 |
| 52 | 3950 | Get rest of course ready | 1d | 2004-01-15 | 2004-01-15 | 51 | 0d |  |  | Instructional Designer | 8h | 216 |
| 53 | 3960 | Revise course | 1d | 2004-01-16 | 2004-01-16 | 52 | 0d |  |  | Instructional Designer; Instructor 2 | 16h | 432 |
| 54 | 3960 | Revise course | 10d | 2004-01-19 | 2004-01-30 | 53, 28 | 0d |  |  | Copy editor | 80h | 1,600 |
| 55 | 3970 | Upload revision | 3d | 2004-02-02 | 2004-02-04 | 54 | 10d |  |  | Sopport person | 24h | 360 |

| ID | WBS | Task | Duration | Start | Finish | Predecessors | Total slack | Free slack | Constraint | Resources | Work | Cost |
| --- | --- | --- | --- | --- | --- | --- | --- | --- | --- | --- | --- | --- |
| 57 | 2000 | **Content Revision Course #3** | 14.5d | 2003-09-17 | 2003-10-07 | 2 | 15d |  |  |  | 136h | 3,736 |
| 58 | 2100 | Create flowchart of current material | 3d | 2003-09-17 | 2003-09-19 | 2 | 15d | 0d | start no earlier than 2003-09-17 | Instructional Designer | 24h | 648 |
| 59 | 2200 | Meet and discuss | 1d | 2003-09-22 | 2003-09-22 | 58 | 15d | 0d |  | Instructional Designer; Project Manager; Instructor 3 | 24h | 712 |
| 60 | 2300 | Revise content | 10d | 2003-09-23 | 2003-10-06 | 59 | 15d | 0d |  | Instructor 3 | 80h | 2,160 |
| 61 | 2400 | Meet and discuss | 0.5d | 2003-10-07 | 2003-10-07 | 60 | 37.5d | 0d |  | Instructional Designer; Instructor 3 | 8h | 216 |
| 62 | 3000 | **Development Course #3** | 97d? | 2003-10-07 | 2004-02-18 | 2 | 0d |  |  |  | 560h | 10,768 |
| 63 | 3100 | Develop templates | 1d? | 2003-10-07 | 2003-10-08 | 61 | 37.5d | 0d |  | Instructional Designer | 8h | 216 |
| 64 | 3200 | Enter text content into templates | 9d | 2003-10-21 | 2003-10-31 | 61, 63, 38 | 3d | 0d |  | Sopport person | 72h | 1,080 |
| 65 | 3300 | **Develop other media** | 41d | 2003-10-07 | 2003-12-02 |  | 15d | 5d |  |  | 248h | 4,776 |
| 66 | 3310 | Develop graphics | 5d | 2003-10-07 | 2003-10-13 | 60 | 15d | 0d |  | Multimedia person | 40h | 720 |
| 67 | 3320 | Enter graphics into templates | 2d | 2003-11-07 | 2003-11-10 | 66, 41 | 3d |  |  | Sopport person | 16h | 240 |
| 68 | 3330 | Develop audio lectures | 5d | 2003-10-07 | 2003-10-14 | 61, 60 | 38.5d | 0d |  | Instructor 3 | 40h | 1,080 |
| 69 | 3330 | Develop audio lectures | 5d | 2003-10-15 | 2003-10-21 | 68, 43 | 42.2d | 0d |  | Developer 1 | 40h | 720 |
| 70 | 3340 | Enter audio lectures into templates | 2d | 2003-10-28 | 2003-10-29 | 69, 44 | 38.2d |  |  | Developer 1 | 16h | 288 |
| 71 | 3350 | Develop animations | 10d | 2003-11-11 | 2003-11-24 | 60, 45 | 15d | 0d |  | Multimedia person | 80h | 1,440 |
| 72 | 3360 | Enter animations into templates | 2d | 2003-12-01 | 2003-12-02 | 71, 46 | 15d |  |  | Multimedia person | 16h | 288 |
| 73 | 3400 | **Get course ready in WebCT** | 75d | 2003-11-06 | 2004-02-18 |  | 0d |  |  |  | 232h | 4,696 |
| 74 | 3410 | Set up course | 2d | 2003-11-06 | 2003-11-07 | 64 | 31.2d | 1d | start no earlier than 2003-11-06 | Instructional Designer | 16h | 432 |
| 75 | 3420 | Upload content material | 5d | 2003-12-24 | 2003-12-30 | 64, 65, 74 | 10d |  | start no earlier than 2003-12-24 | Developer 1 | 40h | 720 |
| 76 | 3430 | Get quizzes ready | 5d | 2004-01-14 | 2004-01-20 | 75, 50 | 5d | 0d |  | Developer 1 | 40h | 720 |
| 77 | 3440 | Get discussions ready | 1d | 2004-01-21 | 2004-01-21 | 76 | 5d | 0d |  | Instructional Designer | 8h | 216 |
| 78 | 3450 | Get rest of course ready | 1d | 2004-01-22 | 2004-01-22 | 77 | 5d | 0d |  | Instructional Designer | 8h | 216 |
| 79 | 3460 | Revise course | 1d | 2004-01-23 | 2004-01-23 | 78 | 5d |  |  | Instructional Designer; Instructor 3 | 16h | 432 |
| 80 | 3460 | Revise course | 10d | 2004-02-02 | 2004-02-13 | 79, 54 | 0d |  |  | Copy editor | 80h | 1,600 |
| 81 | 3470 | Upload revision | 3d | 2004-02-16 | 2004-02-18 | 80 | 0d |  |  | Sopport person | 24h | 360 |

| ID | WBS | Task | Duration | Start | Finish | Predecessors | Total slack | Free slack | Constraint | Resources | Work | Cost |
| --- | --- | --- | --- | --- | --- | --- | --- | --- | --- | --- | --- | --- |
| 83 | 4000 | **Staff Training** | 8d | 2003-10-27 | 2003-11-05 | 2 | 37d |  |  |  | 96h | 2,656 |
| 84 | 4100 | Determine staff needs | 1d | 2003-10-27 | 2003-10-27 |  | 37d | 0d | start no earlier than 2003-10-27 | Instructor 1; Instructor 2; Instructor 3; Instructional Designer; Project Manager | 40h | 1,144 |
| 85 | 4200 | Design and develop workshop | 5d | 2003-10-28 | 2003-11-03 | 84 | 37d | 0d |  | Instructional Designer | 40h | 1,080 |
| 86 | 4300 | Train teachers | 2d | 2003-11-04 | 2003-11-05 | 85 | 37d |  |  | Instructional Designer | 16h | 432 |
| 88 | 5000 | **Course Evaluation** | 2.2d? | 2003-11-10 | 2003-11-12 | 2 | 32.8d |  |  |  | 24h | 660.8 |
| 89 | 5100 | Meet and discuss course evaluation | 0.2d? | 2003-11-10 | 2003-11-10 |  | 32.8d | 0d | start no earlier than 2003-11-10 | Instructor 1; Instructor 2; Instructor 3; Instructional Designer; Project Manager | 8h | 228.8 |
| 90 | 5200 | Design evaluation | 1d? | 2003-11-10 | 2003-11-11 | 89 | 32.8d | 0d |  | Instructional Designer | 8h | 216 |
| 91 | 5300 | Develop evaluation | 1d? | 2003-11-11 | 2003-11-12 | 90 | 32.8d |  |  | Instructional Designer | 8h | 216 |
