# final_project_critical_path_analysis

Schedule from MS Project, 2003-09-01 to 2003-11-10, costs in $.
BBWebmedia

## Calendars

- Standard: Mon-Fri 08:00-12:00, 13:00-17:00; Sat-Sun off.

## Resources

| Resource | Rate | Cost per use |
| --- | --- | --- |
| Instructor 1 |  | 0.27 |
| Instructor 2 | 27 |  |
| Instructor 3 | 27 |  |
| Instructional Designer | 27 |  |
| Developer 1 | 18 |  |
| Multimedia person | 18 |  |
| Copy editor | 20 |  |
| Sopport person | 15 |  |
| Project Manager | 35 |  |

## Schedule

| ID | WBS | Task | Duration | Start | Finish | Predecessors | Total slack | Free slack | Resources | Work | Cost |
| --- | --- | --- | --- | --- | --- | --- | --- | --- | --- | --- | --- |
| 1 | 1000 | **Project scope** | 2d | 2003-09-01 | 2003-09-02 |  | 0d |  |  | 80h | 2,288 |
| 2 | 1100 | Meet and discuss | 2d | 2003-09-01 | 2003-09-02 |  | 0d |  | Instructor 1; Instructor 2; Instructor 3; Instructional Designer; Project Manager | 80h | 2,288 |
| 5 | 2000 | **Content Revision Course #1** | 14.5d | 2003-09-03 | 2003-09-23 | 2 | 0d |  |  | 136h | 3,736 |
| 6 | 2100 | Create flowchart of current material | 3d | 2003-09-03 | 2003-09-05 | 2 | 0d |  | Instructional Designer | 24h | 648 |
| 7 | 2200 | Meet and discuss | 1d | 2003-09-08 | 2003-09-08 | 6 | 0d |  | Instructional Designer; Instructor 1; Project Manager | 24h | 712 |
| 8 | 2300 | Revise content | 10d | 2003-09-09 | 2003-09-22 | 7 | 0d |  | Instructor 1 | 80h | 2,160 |
| 9 | 2400 | Meet and discuss | 0.5d | 2003-09-23 | 2003-09-23 | 8 | 0d |  | Instructor 1; Instructional Designer | 8h | 216 |
| 10 | 3000 | **Development course #1** | 34.5d? | 2003-09-23 | 2003-11-10 | 2 | 0d |  |  | 528h | 10,088 |
| 11 | 3100 | Develop templates | 1d? | 2003-09-23 | 2003-09-24 | 2, 9 | 0d |  | Instructional Designer | 8h | 216 |
| 12 | 3200 | Enter text content into templates | 10d | 2003-09-24 | 2003-10-08 | 11, 9 | 0d |  | Sopport person | 80h | 1,200 |
| 13 | 3300 | **Develop other media** | 12d | 2003-09-23 | 2003-10-08 |  | 1.5d |  |  | 248h | 4,776 |
| 14 | 3310 | Develop graphics | 5d | 2003-09-23 | 2003-09-29 | 8 | 6.5d | 0d | Multimedia person | 40h | 720 |
| 15 | 3320 | Enter graphics into templates | 2d | 2003-09-30 | 2003-10-01 | 14 | 6.5d |  | Sopport person | 16h | 240 |
| 16 | 3330 | Develop audio lectures | 5d | 2003-09-23 | 2003-09-29 | 8 | 1.5d | 0d | Instructor 1 | 40h | 1,080 |
| 17 | 3340 | Develop audio lectures | 5d | 2003-09-30 | 2003-10-06 | 16 | 1.5d | 0d | Developer 1 | 40h | 720 |
| 18 | 3350 | Enter audio lectures into templates | 2d | 2003-10-07 | 2003-10-08 | 17 | 1.5d |  | Developer 1 | 16h | 288 |
| 19 | 3360 | Develop animations | 5d | 2003-09-23 | 2003-09-29 | 8 | 6.5d | 0d | Developer 1; Multimedia person | 80h | 1,440 |
| 20 | 3370 | Enter animations into templates | 2d | 2003-09-30 | 2003-10-01 | 19 | 6.5d |  | Developer 1 | 16h | 288 |
| 21 | 3400 | **Get course ready in WebCT** | 23d | 2003-10-08 | 2003-11-10 |  | 0d |  |  | 192h | 3,896 |
| 22 | 3910 | Set up course | 2d | 2003-10-08 | 2003-10-10 | 12 | 0d |  | Instructional Designer | 16h | 432 |
| 23 | 3920 | Upload content material | 5d | 2003-10-10 | 2003-10-17 | 22, 12, 13 | 0d |  | Developer 1 | 40h | 720 |
| 24 | 3930 | Get quizzes ready | 5d | 2003-10-17 | 2003-10-24 | 23 | 0d |  | Developer 1 | 40h | 720 |
| 25 | 3940 | Get discussions ready | 1d | 2003-10-24 | 2003-10-27 | 24 | 0d |  | Instructional Designer | 8h | 216 |
| 26 | 3950 | Get rest of course ready | 1d | 2003-10-27 | 2003-10-28 | 25 | 0d |  | Instructional Designer | 8h | 216 |
| 27 | 3960 | Revise course | 1d | 2003-10-28 | 2003-10-29 | 26 | 0d |  | Instructional Designer; Instructor 1 | 16h | 432 |
| 28 | 3960 | Revise course | 5d | 2003-10-29 | 2003-11-05 | 27 | 0d |  | Copy editor | 40h | 800 |
| 29 | 3970 | Upload revision | 3d | 2003-11-05 | 2003-11-10 | 28 | 0d |  | Sopport person | 24h | 360 |

| ID | WBS | Task | Duration | Start | Finish | Predecessors | Total slack | Free slack | Resources | Work | Cost |
| --- | --- | --- | --- | --- | --- | --- | --- | --- | --- | --- | --- |
| 31 | 2000 | **Content Revision Course #2** | 14.5d | 2003-09-03 | 2003-09-23 | 2 | 0d |  |  | 136h | 3,736 |
| 32 | 2100 | Create flowchart of current material | 3d | 2003-09-03 | 2003-09-05 | 2 | 0d |  | Instructional Designer | 24h | 648 |
| 33 | 2200 | Meet and discuss | 1d | 2003-09-08 | 2003-09-08 | 32 | 0d |  | Instructional Designer; Project Manager; Instructor 2 | 24h | 712 |
| 34 | 2300 | Revise content | 10d | 2003-09-09 | 2003-09-22 | 33 | 0d |  | Instructor 2 | 80h | 2,160 |
| 35 | 2400 | Meet and discuss | 0.5d | 2003-09-23 | 2003-09-23 | 34 | 0d |  | Instructional Designer; Instructor 2 | 8h | 216 |
| 36 | 3000 | **Development Course 2** | 34.5d? | 2003-09-23 | 2003-11-10 |  | 0d |  |  | 528h | 10,088 |
| 37 | 3100 | Develop templates | 1d? | 2003-09-23 | 2003-09-24 | 35 | 0d |  | Instructional Designer | 8h | 216 |
| 38 | 3200 | Enter text content into templates | 10d | 2003-09-24 | 2003-10-08 | 35, 37 | 0d |  | Sopport person | 80h | 1,200 |
| 39 | 3300 | **Develop other media** | 12d | 2003-09-23 | 2003-10-08 |  | 1.5d |  |  | 248h | 4,776 |
| 40 | 3310 | Develop graphics | 5d | 2003-09-23 | 2003-09-29 | 34 | 6.5d | 0d | Multimedia person | 40h | 720 |
| 41 | 3320 | Enter graphics into templates | 2d | 2003-09-30 | 2003-10-01 | 40 | 6.5d |  | Sopport person | 16h | 240 |
| 42 | 3330 | Develop audio lectures | 5d | 2003-09-23 | 2003-09-29 | 34 | 1.5d | 0d | Instructor 2 | 40h | 1,080 |
| 43 | 3340 | Develop audio lectures | 5d | 2003-09-30 | 2003-10-06 | 42 | 1.5d | 0d | Developer 1 | 40h | 720 |
| 44 | 3350 | Enter audio lectures into templates | 2d | 2003-10-07 | 2003-10-08 | 43 | 1.5d |  | Developer 1 | 16h | 288 |
| 45 | 3360 | Develop animations | 5d | 2003-09-23 | 2003-09-29 | 34 | 6.5d | 0d | Developer 1; Multimedia person | 80h | 1,440 |
| 46 | 3370 | Enter animations into templates | 2d | 2003-09-30 | 2003-10-01 | 45 | 6.5d |  | Developer 1 | 16h | 288 |
| 47 | 3400 | **Get course ready in WebCT** | 23d | 2003-10-08 | 2003-11-10 |  | 0d |  |  | 192h | 3,896 |
| 48 | 3910 | Set up course | 2d | 2003-10-08 | 2003-10-10 | 38 | 0d |  | Instructional Designer | 16h | 432 |
| 49 | 3920 | Upload content material | 5d | 2003-10-10 | 2003-10-17 | 38, 39, 48 | 0d |  | Developer 1 | 40h | 720 |
| 50 | 3930 | Get quizzes ready | 5d | 2003-10-17 | 2003-10-24 | 49 | 0d |  | Developer 1 | 40h | 720 |
| 51 | 3940 | Get discussions ready | 1d | 2003-10-24 | 2003-10-27 | 50 | 0d |  | Instructional Designer | 8h | 216 |
| 52 | 3950 | Get rest of course ready | 1d | 2003-10-27 | 2003-10-28 | 51 | 0d |  | Instructional Designer | 8h | 216 |
| 53 | 3960 | Revise course | 1d | 2003-10-28 | 2003-10-29 | 52 | 0d |  | Instructional Designer; Instructor 2 | 16h | 432 |
| 54 | 3960 | Revise course | 5d | 2003-10-29 | 2003-11-05 | 53 | 0d |  | Copy editor | 40h | 800 |
| 55 | 3970 | Upload revision | 3d | 2003-11-05 | 2003-11-10 | 54 | 0d |  | Sopport person | 24h | 360 |

| ID | WBS | Task | Duration | Start | Finish | Predecessors | Total slack | Free slack | Resources | Work | Cost |
| --- | --- | --- | --- | --- | --- | --- | --- | --- | --- | --- | --- |
| 57 | 2000 | **Content Revision Course #3** | 14.5d | 2003-09-03 | 2003-09-23 | 2 | 0d |  |  | 136h | 3,736 |
| 58 | 2100 | Create flowchart of current material | 3d | 2003-09-03 | 2003-09-05 | 2 | 0d |  | Instructional Designer | 24h | 648 |
| 59 | 2200 | Meet and discuss | 1d | 2003-09-08 | 2003-09-08 | 58 | 0d |  | Instructional Designer; Project Manager; Instructor 3 | 24h | 712 |
| 60 | 2300 | Revise content | 10d | 2003-09-09 | 2003-09-22 | 59 | 0d |  | Instructor 3 | 80h | 2,160 |
| 61 | 2400 | Meet and discuss | 0.5d | 2003-09-23 | 2003-09-23 | 60 | 0d |  | Instructional Designer; Instructor 3 | 8h | 216 |
| 62 | 3000 | **Development Course #3** | 34.5d? | 2003-09-23 | 2003-11-10 |  | 0d |  |  | 528h | 10,088 |
| 63 | 3100 | Develop templates | 1d? | 2003-09-23 | 2003-09-24 | 61 | 0d |  | Instructional Designer | 8h | 216 |
| 64 | 3200 | Enter text content into templates | 10d | 2003-09-24 | 2003-10-08 | 61, 63 | 0d |  | Sopport person | 80h | 1,200 |
| 65 | 3300 | **Develop other media** | 12d | 2003-09-23 | 2003-10-08 |  | 1.5d |  |  | 248h | 4,776 |
| 66 | 3310 | Develop graphics | 5d | 2003-09-23 | 2003-09-29 | 60 | 6.5d | 0d | Multimedia person | 40h | 720 |
| 67 | 3320 | Enter graphics into templates | 2d | 2003-09-30 | 2003-10-01 | 66 | 6.5d |  | Sopport person | 16h | 240 |
| 68 | 3330 | Develop audio lectures | 5d | 2003-09-23 | 2003-09-29 | 60 | 1.5d | 0d | Instructor 3 | 40h | 1,080 |
| 69 | 3330 | Develop audio lectures | 5d | 2003-09-30 | 2003-10-06 | 68 | 1.5d | 0d | Developer 1 | 40h | 720 |
| 70 | 3340 | Enter audio lectures into templates | 2d | 2003-10-07 | 2003-10-08 | 69 | 1.5d |  | Developer 1 | 16h | 288 |
| 71 | 3350 | Develop animations | 5d | 2003-09-23 | 2003-09-29 | 60 | 6.5d | 0d | Developer 1; Multimedia person | 80h | 1,440 |
| 72 | 3360 | Enter animations into templates | 2d | 2003-09-30 | 2003-10-01 | 71 | 6.5d |  | Developer 1 | 16h | 288 |
| 73 | 3400 | **Get course ready in WebCT** | 23d | 2003-10-08 | 2003-11-10 |  | 0d |  |  | 192h | 3,896 |
| 74 | 3410 | Set up course | 2d | 2003-10-08 | 2003-10-10 | 64 | 0d |  | Instructional Designer | 16h | 432 |
| 75 | 3420 | Upload content material | 5d | 2003-10-10 | 2003-10-17 | 64, 65, 74 | 0d |  | Developer 1 | 40h | 720 |
| 76 | 3430 | Get quizzes ready | 5d | 2003-10-17 | 2003-10-24 | 75 | 0d |  | Developer 1 | 40h | 720 |
| 77 | 3440 | Get discussions ready | 1d | 2003-10-24 | 2003-10-27 | 76 | 0d |  | Instructional Designer | 8h | 216 |
| 78 | 3450 | Get rest of course ready | 1d | 2003-10-27 | 2003-10-28 | 77 | 0d |  | Instructional Designer | 8h | 216 |
| 79 | 3460 | Revise course | 1d | 2003-10-28 | 2003-10-29 | 78 | 0d |  | Instructional Designer; Instructor 3 | 16h | 432 |
| 80 | 3460 | Revise course | 5d | 2003-10-29 | 2003-11-05 | 79 | 0d |  | Copy editor | 40h | 800 |
| 81 | 3470 | Upload revision | 3d | 2003-11-05 | 2003-11-10 | 80 | 0d |  | Sopport person | 24h | 360 |

| ID | WBS | Task | Duration | Start | Finish | Predecessors | Total slack | Free slack | Resources | Work | Cost |
| --- | --- | --- | --- | --- | --- | --- | --- | --- | --- | --- | --- |
| 83 | 4000 | **Staff Training** | 8d | 2003-09-03 | 2003-09-12 | 2 | 40.5d |  |  | 96h | 2,656 |
| 84 | 4100 | Determine staff needs | 1d | 2003-09-03 | 2003-09-03 |  | 40.5d | 0d | Instructor 1; Instructor 2; Instructor 3; Instructional Designer; Project Manager | 40h | 1,144 |
| 85 | 4200 | Design and develop workshop | 5d | 2003-09-04 | 2003-09-10 | 84 | 40.5d | 0d | Instructional Designer | 40h | 1,080 |
| 86 | 4300 | Train teachers | 2d | 2003-09-11 | 2003-09-12 | 85 | 40.5d |  | Instructional Designer | 16h | 432 |
| 88 | 5000 | **Course Evaluation** | 2.2d? | 2003-09-03 | 2003-09-05 | 2 | 46.3d |  |  | 24h | 660.8 |
| 89 | 5100 | Meet and discuss course evaluation | 0.2d? | 2003-09-03 | 2003-09-03 |  | 46.3d | 0d | Instructor 1; Instructor 2; Instructor 3; Instructional Designer; Project Manager | 8h | 228.8 |
| 90 | 5200 | Design evaluation | 1d? | 2003-09-03 | 2003-09-04 | 89 | 46.3d | 0d | Instructional Designer | 8h | 216 |
| 91 | 5300 | Develop evaluation | 1d? | 2003-09-04 | 2003-09-05 | 90 | 46.3d |  | Instructional Designer | 8h | 216 |
